# FES constr outine

Schedule from MS Project, 2004-12-27 to 2010-12-31.
BNL

## Calendars

- Standard: Mon-Fri 08:00-12:00, 13:00-17:00; Sat-Sun off.

## Resources

| Resource |
| --- |
| rigging |
| b-tech |
| m-tech |
| contract |
| survey |
| electrician |
| engineer |
| designer |
| t-tech |
| CA tech |

## Schedule

| ID | WBS | Task | Type | Duration | Start | Finish | Total slack | Constraint | Resources | Work |
| --- | --- | --- | --- | --- | --- | --- | --- | --- | --- | --- |
| 1 | 1 | FES Construction outline |  | 1570d | 2004-12-27 | 2010-12-31 | 0d | start no earlier than 2004-12-27 |  |  |
| 3 | 2 | RHIC running |  | 758d | 2005-10-03 | 2010-05-11 | 168d | start no earlier than 2005-10-02 |  |  |
| 4 | 3 | SEB beam tests |  | 386d | 2007-12-03 | 2010-05-14 | 165d | start no earlier than 2007-12-01 |  |  |
| 5 | 4 | RSVP engineering runs |  | 246d | 2008-12-01 | 2010-05-10 | 169d | start no earlier than 2008-12-01 |  |  |
| 7 | 5 | STAR |  | 1d? | 2005-10-03 | 2005-10-03 | 1369d |  |  |  |
| 8 | 6 | install STAR equipment |  | 432d | 2006-05-29 | 2009-10-29 | 306d | start no earlier than 2006-05-28 | m-tech [150%] | 5184h |
| 10 | 7 | PHENIX |  | 1d | 2005-10-03 | 2005-10-03 | 1369d |  |  |  |
| 11 | 8 | install Phenix equipment |  | 432d | 2006-05-29 | 2009-10-16 | 315d | start no earlier than 2006-05-28 | m-tech [150%] | 5184h |
| 13 | 9 | BRAHMS & PHOBOS |  | 1d | 2004-12-31 | 2004-12-31 | 1565d | start no earlier than 2004-12-31 |  |  |
| 14 | 10 | install experimental equipment |  | 432d | 2006-05-22 | 2009-10-16 | 315d | start no earlier than 2006-05-21 | m-tech [50%] | 1728h |
| 16 | 11 | RHIC |  | 1d? | 2005-10-03 | 2005-10-03 | 1369d |  |  |  |
| 17 | 12 | summer upgrade support |  | 432d | 2006-05-22 | 2009-10-16 | 315d | start no earlier than 2006-05-21 | b-tech [300%] | 10368h |
| 18 | 13 | summer upgrade survey support |  | 432d | 2006-05-22 | 2009-10-15 | 316d | start no earlier than 2006-05-21 | survey [300%] | 10368h |
| 19 | 14 | summer upgrade support |  | 430d | 2006-05-29 | 2009-10-22 | 311d | start no earlier than 2006-05-28 | t-tech [800%] | 27520h |
| 20 | 15 | operations support |  | 750d | 2005-10-31 | 2010-05-21 | 160d | start no earlier than 2005-10-30 | m-tech [150%] | 9000h |
| 21 | 16 | operations support |  | 750d | 2005-10-31 | 2010-05-20 | 161d | start no earlier than 2005-10-30 | b-tech | 6000h |
| 22 | 17 | operations support |  | 750d | 2005-10-31 | 2010-05-24 | 159d | start no earlier than 2005-10-31 | t-tech [1200%] | 72000h |
| 23 | 18 | operations support |  | 1195d? | 2005-10-31 | 2010-05-28 | 155d | start no earlier than 2005-10-31 | rigging [300%] | 28680h |
| 24 | 19 | operations support |  | 1195d? | 2005-10-31 | 2010-05-28 | 155d | finish no earlier than 2010-05-28 | electrician [300%] | 28680h |
| 25 | 20 | operations support |  | 1196d | 2005-10-31 | 2010-05-31 | 154d | start no earlier than 2005-10-31 | CA tech [5500%] | 526240h |
| 26 | 21 | operations support |  | 1196d | 2005-11-01 | 2010-06-01 | 153d | start no earlier than 2005-11-01 | engineer [3000%] | 287040h |
| 27 | 22 | operations support |  | 1196d | 2005-11-01 | 2010-06-01 | 153d | start no earlier than 2005-11-01 | designer [1500%] | 143520h |
| 30 | 23 | 926 | milestone | 0d | 2005-10-01 | 2005-10-01 | 1370d |  |  |  |
| 31 | 24 | **remove existing beam** |  | 132d | 2005-10-03 | 2006-04-04 | 1238d |  |  | 3872h |
| 32 | 24.1 | remove equip B-1 / B-5 / B-2 |  | 44d | 2005-10-03 | 2006-03-23 | 1246d |  | rigging [300%] | 1056h |
| 33 | 24.2 | disc equipment B-1 / B-5 / B2 |  | 132d | 2005-10-03 | 2006-04-04 | 1238d | start no earlier than 2005-10-01 | b-tech | 1056h |
| 34 | 24.3 | disc equipment B-1 / B-5 / B2 |  | 132d | 2005-10-03 | 2006-04-04 | 1238d | start no earlier than 2005-10-01 | m-tech | 1056h |
| 35 | 24.4 | remove equipment B-1 / B-5 / B2 |  | 44d | 2005-10-03 | 2006-03-24 | 1245d | start no earlier than 2005-10-01 | electrician [200%] | 704h |

| ID | WBS | Task | Type | Duration | Start | Finish | Predecessors | Total slack | Free slack | Constraint | Resources | Work |
| --- | --- | --- | --- | --- | --- | --- | --- | --- | --- | --- | --- | --- |
| 36 | 25 | **prepare new equipment** |  | 475d | 2006-01-02 | 2007-10-26 |  | 830d |  |  |  | 8536h |
| 37 | 25.1 | prepare PS's and controls |  | 110d | 2006-05-01 | 2006-09-29 |  | 1110d |  | start no earlier than 2006-05-01 | t-tech [400%] | 3520h |
| 38 | 25.2 | prepare transport magnets |  | 90d | 2006-01-02 | 2006-05-05 |  | 1215d |  | start no earlier than 2006-01-01 | m-tech | 720h |
| 39 | 25.3 | prepare neutral bm. Sweepers |  | 280d | 2006-10-02 | 2007-10-26 |  | 830d |  | start no earlier than 2006-10-01 | m-tech [150%] | 3360h |
| 40 | 25.4 | magnet interlock wiring |  | 78d | 2006-12-01 | 2007-10-12 |  | 840d |  | start no earlier than 2006-12-01 | b-tech [150%] | 936h |
| 41 | 26 | **install new primary beam** |  | 241d | 2006-05-01 | 2007-04-02 |  | 979d |  |  |  | 8624h |
| 42 | 26.1 | reconfigure B line |  | 110d | 2006-05-01 | 2007-02-16 |  | 1010d |  | start no earlier than 2006-05-01 | rigging [300%] | 2640h |
| 43 | 26.2 | install B line transport |  | 132d | 2006-06-01 | 2006-12-01 |  | 1065d |  | start no earlier than 2006-06-01 | m-tech | 1056h |
| 44 | 26.3 | install B instrumentation |  | 66d | 2006-10-02 | 2007-01-01 |  | 1044d |  | start no earlier than 2006-10-01 | CA tech [200%] | 1056h |
| 45 | 26.4 | install B line transport |  | 132d | 2006-06-01 | 2006-12-01 |  | 1065d |  | start no earlier than 2006-06-01 | b-tech [200%] | 2112h |
| 46 | 26.5 | survey B transport |  | 44d | 2006-07-03 | 2006-12-27 |  | 1047d |  | start no earlier than 2006-07-01 | survey [200%] | 704h |
| 47 | 26.6 | install rad security system |  | 66d | 2007-01-01 | 2007-04-02 |  | 979d |  | start no earlier than 2007-01-01 | CA tech [200%] | 1056h |
| 48 | 27 | **install neutral beam** |  | 326d | 2007-06-01 | 2008-09-01 |  | 610d |  |  |  | 12464h |
| 49 | 27.1 | install neutral beam & target station |  | 154d | 2007-06-01 | 2008-07-04 |  | 650d |  | start no earlier than 2007-06-01 | rigging [300%] | 3696h |
| 50 | 27.2 | install neutral beam & target station |  | 240d | 2007-09-03 | 2008-08-01 |  | 630d |  | start no earlier than 2007-09-01 | m-tech [200%] | 3840h |
| 51 | 27.3 | install neutral beam & target station |  | 132d | 2008-02-01 | 2008-08-04 |  | 629d |  | start no earlier than 2008-02-01 | b-tech [200%] | 2112h |
| 52 | 27.4 | install neutral beam & target station |  | 88d | 2007-09-03 | 2008-08-08 |  | 625d |  | start no earlier than 2007-09-01 | survey [200%] | 1408h |
| 53 | 27.5 | controls system integration & tests |  | 44d | 2008-07-01 | 2008-08-29 |  | 610d |  | start no earlier than 2008-07-01 | CA tech [200%] | 704h |
| 54 | 27.6 | R&T beam line components |  | 44d | 2008-07-01 | 2008-08-29 |  | 610d |  | start no earlier than 2008-07-01 | t-tech [200%] | 704h |
| 55 | 27.7 | neutral bm complete | milestone | 0d | 2008-09-01 | 2008-09-01 |  | 610d |  | start no earlier than 2008-09-01 |  |  |
| 56 | 28 | 25Mz cavity & A-10 kicker installed | milestone | 0d | 2007-10-01 | 2007-10-01 |  | 850d |  | start no earlier than 2007-10-01 | CA tech [200%] |  |
| 57 | 29 | 100Mz cavity installed | milestone | 0d | 2009-10-01 | 2009-10-01 |  | 327d |  | start no earlier than 2009-10-01 |  |  |
| 58 | 30 | **Experimental support** |  | 940d | 2007-02-01 | 2010-09-08 |  | 82d |  |  |  | 17888h |
| 59 | 30.1 | construct pit |  | 88d | 2007-02-01 | 2007-06-04 |  | 934d |  | start no earlier than 2007-02-01 | contract | 704h |
| 60 | 30.2 | decay tank vac assembly |  | 88d | 2008-09-01 | 2008-12-31 |  | 522d |  | start no earlier than 2008-09-01 | CA tech [200%] | 1408h |
| 61 | 30.3 | assemble 48D48 |  | 41d | 2008-12-01 | 2009-01-26 |  | 480d | 0d | start no earlier than 2008-12-01 | m-tech [200%] | 656h |
| 62 | 30.4 | assemble 48D48 |  | 24d | 2009-01-27 | 2009-02-27 | 61 | 480d |  | start no earlier than 2004-09-06 | b-tech [300%] | 576h |
| 63 | 30.5 | install experimental equipment |  | 300d | 2008-09-01 | 2010-07-16 |  | 120d |  | start no earlier than 2008-09-01 | m-tech | 2400h |
| 64 | 30.6 | install experimental equipment |  | 126d | 2007-10-01 | 2009-12-21 |  | 269d |  | start no earlier than 2007-10-01 | rigging [300%] | 3120h |
| 65 | 30.7 | install experimental equipment |  | 264d | 2007-07-02 | 2010-07-30 |  | 110d |  | start no earlier than 2007-07-01 | electrician [200%] | 4224h |
| 66 | 30.8 | install experimental equipment |  | 300d | 2007-10-01 | 2010-09-08 |  | 82d |  | start no earlier than 2007-10-01 | survey | 2400h |
| 67 | 30.9 | install experimental equipment |  | 300d | 2009-01-01 | 2010-07-28 |  | 112d |  | start no earlier than 2009-01-01 | b-tech | 2400h |

| ID | WBS | Task | Type | Duration | Start | Finish | Total slack | Constraint | Resources | Work |
| --- | --- | --- | --- | --- | --- | --- | --- | --- | --- | --- |
| 68 | 31 | **project support and design** |  | 1200d | 2005-10-03 | 2010-05-07 | 170d |  |  | 15768h |
| 69 | 31.1 | project support |  | 1200d | 2005-10-03 | 2010-05-07 | 170d | start no earlier than 2005-10-01 | engineer [65%] | 6240h |
| 70 | 31.2 | equipment design |  | 344d | 2005-11-01 | 2007-02-23 | 1005d | start no earlier than 2005-11-01 | engineer [150%] | 4128h |
| 71 | 31.3 | equipment design |  | 450d | 2006-01-03 | 2007-09-24 | 854d | start no earlier than 2006-01-03 | designer [150%] | 5400h |
| 76 | 32 | **Switchyard Modifications** |  | 262d? | 2007-01-01 | 2008-01-01 | 783d |  |  | 12848h |
| 77 | 32.1 | prepare new transport magnets |  | 66d | 2007-01-01 | 2007-04-02 | 979d | start no earlier than 2007-01-01 | m-tech | 528h |
| 78 | 32.2 | prepare power supplies |  | 120d? | 2007-05-01 | 2007-10-15 | 839d | start no earlier than 2007-05-01 | t-tech [400%] | 3840h |
| 79 | 32.3 | disc magnets |  | 40d | 2007-05-01 | 2007-06-25 | 919d | start no earlier than 2007-05-01 | b-tech [200%] | 640h |
| 80 | 32.4 | disc magnets & vacuum |  | 30d | 2007-05-01 | 2007-06-11 | 929d | start no earlier than 2007-05-01 | m-tech | 240h |
| 81 | 32.5 | remove magnets |  | 20d | 2007-06-01 | 2007-06-28 | 916d | start no earlier than 2007-06-01 | rigging [300%] | 480h |
| 82 | 32.6 | install shielding at AD2 |  | 10d? | 2007-07-02 | 2007-07-13 | 905d | start no earlier than 2007-07-01 | rigging [300%] | 240h |
| 83 | 32.7 | hookup magnets |  | 88d | 2007-07-02 | 2007-10-31 | 827d | start no earlier than 2007-07-01 | b-tech [200%] | 1408h |
| 84 | 32.8 | hookup magnets and vacuum |  | 88d | 2007-07-02 | 2007-10-31 | 827d | start no earlier than 2007-07-01 | m-tech | 704h |
| 85 | 32.9 | electrical mods |  | 56d | 2007-06-01 | 2007-11-29 | 806d | start no earlier than 2007-06-01 | electrician [200%] | 896h |
| 86 | 32.10 | prepare & install beam stops |  | 44d | 2007-02-01 | 2007-07-17 | 903d | start no earlier than 2007-02-01 | m-tech | 352h |
| 87 | 32.11 | survey equipment |  | 44d | 2007-06-01 | 2007-09-17 | 859d | start no earlier than 2007-06-01 | survey [200%] | 704h |
| 88 | 32.12 | install instrumentation |  | 88d | 2007-05-28 | 2007-09-26 | 852d | start no earlier than 2007-05-28 | CA tech | 704h |
| 89 | 32.13 | install rad security system |  | 88d | 2007-07-02 | 2007-10-31 | 827d | start no earlier than 2007-07-01 | CA tech | 704h |
| 90 | 32.14 | controls system integration & tests |  | 44d | 2007-11-01 | 2008-01-01 | 783d | start no earlier than 2007-11-01 | CA tech [200%] | 704h |
| 91 | 32.15 | R&T beam line components |  | 44d | 2007-11-01 | 2008-01-01 | 783d | start no earlier than 2007-11-01 | t-tech [200%] | 704h |
| 92 | 33 | **D line available** |  | 400d | 2005-10-03 | 2007-04-13 | 970d |  |  | 800h |
| 93 | 33.1 | maintain "D" components |  | 400d | 2005-10-03 | 2007-04-13 | 970d |  | b-tech [25%] | 800h |
| 94 | 34 | SYG ready | milestone | 0d | 2008-01-01 | 2008-01-01 | 784d | start no earlier than 2008-01-01 |  |  |
| 95 | 35 | **Project support and design** |  | 540d | 2005-10-03 | 2007-10-26 | 830d |  |  | 5272h |
| 96 | 35.1 | Project support |  | 540d | 2005-10-03 | 2007-10-26 | 830d | start no earlier than 2005-10-01 | engineer [25%] | 1080h |
| 97 | 35.2 | equipment design |  | 330d | 2005-11-01 | 2007-02-05 | 1019d | start no earlier than 2005-11-01 | engineer | 2640h |
| 98 | 35.3 | equipment design |  | 388d | 2006-01-02 | 2007-06-27 | 917d | start no earlier than 2006-01-01 | designer [50%] | 1552h |
| 103 | 36 | 940 | milestone | 0d | 2005-10-01 | 2005-10-01 | 1370d | start no earlier than 2005-10-01 |  |  |

| ID | WBS | Task | Type | Duration | Start | Finish | Total slack | Constraint | Resources | Work |
| --- | --- | --- | --- | --- | --- | --- | --- | --- | --- | --- |
| 104 | 37 | **remove existing beam** |  | 88d | 2005-10-03 | 2006-02-01 | 1282d |  |  | 4400h |
| 105 | 37.1 | disc "A" line equipment |  | 22d | 2005-10-03 | 2005-11-01 | 1348d | start no earlier than 2005-10-01 | m-tech [150%] | 264h |
| 106 | 37.2 | disc "A" line equipment |  | 22d | 2005-10-03 | 2005-11-01 | 1348d | start no earlier than 2005-10-01 | b-tech [150%] | 264h |
| 107 | 37.3 | remove roof & equip. |  | 66d | 2005-10-03 | 2006-01-02 | 1304d | start no earlier than 2005-10-01 | rigging [300%] | 1584h |
| 108 | 37.4 | remove ac & dc cables |  | 44d | 2005-12-01 | 2006-01-31 | 1283d | start no earlier than 2005-12-01 | b-tech [300%] | 1056h |
| 109 | 37.5 | remove wc bus and hose |  | 44d | 2005-12-01 | 2006-01-31 | 1283d | start no earlier than 2005-12-01 | m-tech [150%] | 528h |
| 110 | 37.6 | remove tray & power |  | 44d | 2005-10-03 | 2006-02-01 | 1282d | start no earlier than 2005-10-01 | electrician [200%] | 704h |
| 111 | 38 | **prepare new equipment** |  | 188d | 2006-01-02 | 2006-09-20 | 1117d |  |  | 3008h |
| 112 | 38.1 | prepare "A" transport magnets |  | 188d | 2006-01-02 | 2006-09-20 | 1117d | start no earlier than 2006-01-01 | m-tech [150%] | 2256h |
| 113 | 38.2 | wire interlocks- "A" trans magnets |  | 28d | 2006-05-01 | 2006-09-20 | 1117d | start no earlier than 2006-05-01 | b-tech | 224h |
| 114 | 38.3 | assemble magnet monitor PLC |  | 44d | 2006-06-01 | 2006-08-01 | 1153d | start no earlier than 2006-06-01 | b-tech | 352h |
| 115 | 38.4 | modify ROYALS |  | 22d | 2006-03-01 | 2006-03-30 | 1241d | start no earlier than 2006-03-01 | electrician | 176h |
| 116 | 39 | **install primary beam** |  | 433d | 2006-02-01 | 2007-10-01 | 850d |  |  | 23024h |
| 117 | 39.1 | reconfigure "A" prim cave |  | 176d | 2006-02-01 | 2006-12-06 | 1062d | start no earlier than 2006-02-01 | rigging [300%] | 4224h |
| 118 | 39.2 | modify power supplies for new controls |  | 123d | 2006-04-03 | 2006-09-20 | 1117d | start no earlier than 2006-04-01 | t-tech [400%] | 3936h |
| 119 | 39.3 | run w.c. bus to transport magnets |  | 110d | 2006-06-01 | 2006-11-01 | 1087d | start no earlier than 2006-06-01 | m-tech [200%] | 1760h |
| 120 | 39.4 | install "A" transport equip |  | 100d | 2006-11-01 | 2007-03-20 | 988d | start no earlier than 2006-11-01 | m-tech [200%] | 1600h |
| 121 | 39.5 | install "A" transport equip |  | 132d | 2006-11-01 | 2007-05-03 | 956d | start no earlier than 2006-11-01 | b-tech [400%] | 4224h |
| 122 | 39.6 | install tray & power |  | 110d | 2006-06-01 | 2007-03-13 | 993d | start no earlier than 2006-06-01 | electrician [200%] | 1760h |
| 123 | 39.7 | install "A" transport equip |  | 54d | 2006-11-01 | 2007-03-14 | 992d | start no earlier than 2006-11-01 | rigging [300%] | 1296h |
| 124 | 39.8 | install beam line instrumentation |  | 88d | 2007-03-01 | 2007-07-02 | 914d | start no earlier than 2007-03-01 | CA tech [200%] | 1408h |
| 125 | 39.9 | survey "A" transport |  | 44d | 2006-09-01 | 2007-02-20 | 1008d | start no earlier than 2006-09-01 | survey [200%] | 704h |
| 126 | 39.10 | install rad security system |  | 44d | 2007-01-01 | 2007-03-01 | 1001d | start no earlier than 2007-01-01 | CA tech [200%] | 704h |
| 127 | 39.11 | controls system integration & tests |  | 44d | 2007-07-02 | 2007-08-30 | 871d | start no earlier than 2007-07-01 | CA tech [200%] | 704h |
| 128 | 39.12 | R&T Bm line |  | 44d | 2007-07-02 | 2007-08-30 | 871d | start no earlier than 2007-07-01 | t-tech [200%] | 704h |
| 129 | 39.13 | beam line ready for tests | milestone | 0d | 2007-10-01 | 2007-10-01 | 850d | start no earlier than 2007-10-01 |  |  |
| 130 | 40 | AC dipole & kickers ready | milestone | 0d | 2007-10-01 | 2007-10-01 | 850d | start no earlier than 2007-10-01 |  |  |
| 131 | 41 | New extraction system ready | milestone | 0d | 2008-10-01 | 2008-10-01 | 588d | start no earlier than 2008-10-01 |  |  |

| ID | WBS | Task | Type | Duration | Start | Finish | Predecessors | Total slack | Free slack | Constraint | Resources | Work |
| --- | --- | --- | --- | --- | --- | --- | --- | --- | --- | --- | --- | --- |
| 132 | 42 | **RFMM installation in extracted beam** |  | 328d? | 2008-01-01 | 2009-04-02 |  | 456d |  |  |  | 1736h |
| 133 | 42.1 | install RFMM prototype |  | 10d? | 2008-01-01 | 2008-01-14 |  | 774d |  | start no earlier than 2008-01-01 | rigging [300%] | 240h |
| 134 | 42.2 | hookup RFMM prototype |  | 44d | 2008-01-01 | 2008-02-29 |  | 740d |  | start no earlier than 2008-01-01 | CA tech [200%] | 704h |
| 135 | 42.3 | hookup RFMM |  | 66d | 2009-01-01 | 2009-04-02 |  | 456d |  | start no earlier than 2009-01-01 | CA tech [150%] | 792h |
| 136 | 43 | **Prepare compressor area** |  | 198d? | 2008-01-01 | 2008-10-02 |  | 586d |  |  |  | 3712h |
| 137 | 43.1 | Prepare cyro refr & compr area |  | 44d | 2008-01-01 | 2008-02-29 |  | 740d |  | start no earlier than 2008-01-01 | m-tech | 352h |
| 138 | 43.2 | Prepare cyro refr & compr area |  | 44d | 2008-01-01 | 2008-02-29 |  | 740d |  | start no earlier than 2008-01-01 | b-tech [200%] | 704h |
| 139 | 43.3 | install compressors & storage tanks |  | 22d | 2008-03-03 | 2008-04-01 |  | 718d |  | start no earlier than 2008-03-01 | rigging [300%] | 528h |
| 140 | 43.4 | power compressors & refrig |  | 88d | 2008-06-02 | 2008-10-01 |  | 587d |  | start no earlier than 2008-06-01 | electrician [200%] | 1408h |
| 141 | 43.5 | install compressor water cooling |  | 45d? | 2008-08-01 | 2008-10-02 |  | 586d |  | start no earlier than 2008-08-01 | CA tech [200%] | 720h |
| 142 | 44 | **Solenoid installation** |  | 261d | 2009-01-01 | 2009-12-31 |  | 261d |  |  |  | 3528h |
| 143 | 44.1 | remove temporary beam stop |  | 22d | 2009-01-01 | 2009-01-30 |  | 500d |  | start no earlier than 2009-01-01 | rigging [300%] | 528h |
| 144 | 44.2 | install TS & DS solenoids |  | 22d | 2009-02-02 | 2009-03-03 |  | 265d | 0d | start no earlier than 2009-02-01 | rigging [300%] | 528h |
| 145 | 44.3 | survey TS & DS solenoids |  | 15d | 2009-03-04 | 2009-03-24 | 144 | 265d | 0d | start no earlier than 2008-02-01 | survey [300%] | 360h |
| 146 | 44.4 | hookup TS & DS solenoids |  | 198d | 2009-03-25 | 2009-12-25 | 145 | 265d |  | start no earlier than 2008-02-01 |  |  |
| 147 | 44.5 | install cosmic ray shield |  | 66d | 2009-05-01 | 2009-12-21 |  | 269d |  | start no earlier than 2009-05-01 | rigging [300%] | 1584h |
| 148 | 44.6 | PS solenoid delivered | milestone | 0d | 2009-08-01 | 2009-08-01 |  | 370d |  | start no earlier than 2009-08-01 |  |  |
| 149 | 44.7 | install production solenoid & heat shield |  | 22d | 2009-09-01 | 2009-09-30 |  | 261d | 0d | start no earlier than 2009-09-01 | rigging [300%] | 528h |
| 150 | 44.8 | hookup production solenoid |  | 66d | 2009-10-01 | 2009-12-31 | 149 | 261d | 0d | start no earlier than 2009-10-01 |  |  |
| 151 | 44.9 | Solenoid acceptance tests | milestone | 0d | 2009-12-31 | 2009-12-31 | 150 | 261d |  |  |  |  |
| 152 | 45 | **Experimental support** |  | 309d | 2009-08-03 | 2010-10-07 |  | 61d |  |  |  | 5648h |
| 153 | 45.1 | install counting house |  | 88d | 2009-08-03 | 2009-12-02 |  | 282d |  | start no earlier than 2009-08-01 | contract | 704h |
| 154 | 45.2 | assist with detector installation |  | 200d | 2010-01-01 | 2010-10-07 |  | 61d |  | start no earlier than 2010-01-01 | b-tech [50%] | 800h |
| 155 | 45.3 | assist with detector installation |  | 200d | 2010-01-01 | 2010-10-07 |  | 61d |  | start no earlier than 2010-01-01 | m-tech [50%] | 800h |
| 156 | 45.4 | survey detectors |  | 66d | 2010-03-01 | 2010-09-27 |  | 69d |  | start no earlier than 2010-03-01 | survey [300%] | 1584h |
| 157 | 45.5 | assemble electronics hut |  | 22d | 2009-09-01 | 2009-09-30 |  | 327d |  | start no earlier than 2009-09-01 |  |  |
| 158 | 45.6 | install power/tray in electronics hut & DS |  | 66d | 2009-10-01 | 2009-12-31 |  | 261d |  | start no earlier than 2009-10-01 | electrician [200%] | 1056h |
| 159 | 45.7 | install power in counting house |  | 44d | 2010-01-01 | 2010-03-03 |  | 217d |  | start no earlier than 2010-01-01 | electrician [200%] | 704h |

| ID | WBS | Task | Type | Duration | Start | Finish | Total slack | Constraint | Resources | Work |
| --- | --- | --- | --- | --- | --- | --- | --- | --- | --- | --- |
| 160 | 46 | **Project support and design** |  | 1200d? | 2005-10-03 | 2010-05-07 | 170d |  |  | 24672h |
| 161 | 46.1 | Project support |  | 1200d? | 2005-10-03 | 2010-05-07 | 170d |  | engineer [65%] | 6240h |
| 162 | 46.2 | equipment design |  | 564d? | 2005-11-01 | 2007-12-28 | 785d | start no earlier than 2005-11-01 | engineer [200%] | 9024h |
| 163 | 46.3 | equipment design |  | 588d | 2006-01-02 | 2008-04-02 | 717d | start no earlier than 2006-01-02 | designer [200%] | 9408h |
| 167 | 47 | **Booster Modifications** |  | 508d? | 2005-10-03 | 2007-09-12 | 862d |  |  | 23096h |
| 168 | 47.1 | install booster cap |  | 66d | 2006-06-01 | 2006-08-31 | 1131d | start no earlier than 2006-06-01 | contract | 528h |
| 169 | 47.2 | Instrument upgrade / C3 protection |  | 500d | 2005-10-03 | 2007-08-31 | 870d | start no earlier than 2005-10-01 | CA tech | 4000h |
| 170 | 47.3 | mechanical mods |  | 239d | 2006-03-01 | 2007-08-27 | 874d | start no earlier than 2006-03-01 | CA tech [400%] | 7648h |
| 171 | 47.4 | RF mods |  | 352d | 2006-05-01 | 2007-09-04 | 868d | start no earlier than 2006-05-01 | CA tech [150%] | 4224h |
| 172 | 47.5 | electrical mods |  | 250d? | 2006-05-01 | 2007-09-12 | 862d | start no earlier than 2006-05-01 | CA tech [150%] | 3000h |
| 173 | 47.6 | rigging support |  | 66d | 2006-05-01 | 2007-07-16 | 904d | start no earlier than 2006-05-01 | rigging [300%] | 1584h |
| 174 | 47.7 | electrical support |  | 88d? | 2006-05-01 | 2007-07-31 | 893d | start no earlier than 2006-05-01 | electrician [200%] | 1408h |
| 175 | 47.8 | survey equipment |  | 44d | 2006-08-01 | 2007-07-27 | 895d | start no earlier than 2006-08-01 | survey [200%] | 704h |
| 177 | 48 | AGS Modifications | milestone | 0d | 2005-10-01 | 2005-10-01 | 1370d |  |  |  |
| 178 | 49 | **AGS ALARA improvements** |  | 871d | 2006-05-01 | 2009-08-31 | 349d |  |  | 11376h |
| 179 | 49.1 | install cap over ring |  | 266d | 2006-05-01 | 2008-09-24 | 592d | start no earlier than 2006-05-01 | contract | 2128h |
| 180 | 49.2 | dipole coil replacement |  | 160d | 2006-06-01 | 2007-09-18 | 858d | start no earlier than 2006-06-01 | CA tech [200%] | 2560h |
| 181 | 49.3 | rigging support |  | 88d | 2006-06-01 | 2009-07-03 | 390d | start no earlier than 2006-06-01 | rigging [300%] | 2112h |
| 182 | 49.4 | electrical support |  | 66d | 2006-06-01 | 2008-07-02 | 652d | start no earlier than 2006-06-01 | electrician [200%] | 1056h |
| 183 | 49.5 | survey equipment |  | 88d | 2006-08-01 | 2009-07-08 | 387d | start no earlier than 2006-08-01 | survey [200%] | 1408h |
| 184 | 49.6 | assemble collimators |  | 132d | 2008-10-01 | 2009-04-02 | 456d | start no earlier than 2008-10-01 | CA tech | 1056h |
| 185 | 49.7 | install collimators |  | 66d | 2009-06-01 | 2009-08-31 | 349d | start no earlier than 2009-06-01 | CA tech [200%] | 1056h |
| 186 | 50 | **Extraction system upgrade** |  | 649d? | 2006-04-03 | 2008-09-25 | 591d |  |  | 12964h |
| 187 | 50.1 | install spare F-10 |  | 44d | 2006-06-01 | 2006-08-01 | 1153d | start no earlier than 2006-06-01 | CA tech [200%] | 704h |
| 188 | 50.2 | prepare new spare F-10 |  | 115d | 2006-09-01 | 2007-02-08 | 1016d | start no earlier than 2006-09-01 | CA tech [150%] | 1380h |
| 189 | 50.3 | upgrade F-5 / F-10 PS's |  | 125d | 2006-08-01 | 2007-08-17 | 880d | start no earlier than 2006-08-01 | CA tech | 1000h |
| 190 | 50.4 | modify J-10 bump for low ripple |  | 15d | 2007-06-01 | 2007-06-21 | 921d | start no earlier than 2007-06-01 | CA tech [200%] | 240h |
| 191 | 50.5 | upgrade PFN's |  | 185d | 2006-06-01 | 2007-10-16 | 838d | start no earlier than 2006-06-01 | CA tech | 1480h |
| 192 | 50.6 | prepare & install H-20 (+spare) |  | 200d | 2007-12-03 | 2008-09-05 | 605d | start no earlier than 2007-12-01 | CA tech | 1600h |
| 193 | 50.7 | prepare & install new F-5 (+spare) |  | 221d | 2007-11-01 | 2008-09-04 | 606d | start no earlier than 2007-11-01 | CA tech [200%] | 3536h |
| 194 | 50.8 | upgrade instrumentation |  | 378d? | 2006-04-03 | 2008-09-25 | 591d | start no earlier than 2006-04-01 | CA tech | 3024h |
| 195 | 51 | new extraction system ready | milestone | 0d | 2008-10-01 | 2008-10-01 | 588d | start no earlier than 2008-10-01 |  |  |

| ID | WBS | Task | Type | Duration | Start | Finish | Total slack | Constraint | Resources | Work |
| --- | --- | --- | --- | --- | --- | --- | --- | --- | --- | --- |
| 196 | 52 | **Experiment specific upgrades** |  | 827d | 2006-08-01 | 2009-09-30 | 327d |  |  | 14824h |
| 197 | 52.1 | modify AC dipole & PS |  | 88d | 2007-05-01 | 2007-08-30 | 871d | start no earlier than 2007-05-01 | CA tech [200%] | 1408h |
| 198 | 52.2 | build & install strip line kickers & ps |  | 164d | 2007-01-01 | 2007-08-16 | 881d | start no earlier than 2007-01-01 | CA tech | 1312h |
| 199 | 52.3 | 25mz RF cavity drive r/ LL controls |  | 175d | 2007-01-01 | 2007-08-31 | 870d | start no earlier than 2007-01-01 | CA tech | 1400h |
| 200 | 52.4 | install A-10 PS building & access port |  | 88d | 2006-08-01 | 2006-11-30 | 1066d | start no earlier than 2006-08-01 | contract | 704h |
| 201 | 52.5 | install A-10 PS & kicker |  | 125d | 2007-02-01 | 2007-07-25 | 897d | start no earlier than 2007-02-01 | CA tech [200%] | 2000h |
| 202 | 52.6 | build & install 100Mz RF cavity |  | 500d | 2007-11-01 | 2009-09-30 | 327d | start no earlier than 2007-11-01 | CA tech [200%] | 8000h |
| 203 | 53 | AC dipole & strip line kickers ready | milestone | 0d | 2007-10-01 | 2007-10-01 | 850d | start no earlier than 2007-10-01 |  |  |
| 204 | 54 | 25Mz RF cavity & A-10 ready | milestone | 0d | 2007-10-01 | 2007-10-01 | 850d | start no earlier than 2007-10-01 |  |  |
| 205 | 55 | 100Mz RF cavity ready | milestone | 0d | 2009-10-01 | 2009-10-01 | 327d | start no earlier than 2009-10-01 |  |  |
| 206 | 56 | **AGS / Booster Project support & design** |  | 1045d? | 2005-10-03 | 2009-10-02 | 325d |  |  | 60744h |
| 207 | 56.1 | Project support |  | 1045d? | 2005-10-03 | 2009-10-02 | 325d | finish no earlier than 2009-10-02 | engineer | 8360h |
| 208 | 56.2 | cap & facility design |  | 333.33d? | 2005-10-03 | 2007-01-11 | 1036.67d |  | engineer [75%] | 2000h |
| 209 | 56.3 | equipment design |  | 666.67d | 2005-10-03 | 2008-04-22 | 703.33d | start no earlier than 2005-10-01 | engineer [300%] | 16000h |
| 210 | 56.4 | equipment design |  | 698.67d? | 2006-04-03 | 2008-12-04 | 541.33d | start no earlier than 2006-04-01 | engineer [150%] | 8384h |
| 211 | 56.5 | equipment design |  | 500d? | 2005-11-01 | 2007-10-01 | 849d | start no earlier than 2005-11-01 | designer [200%] | 8000h |
| 212 | 56.6 | equipment design |  | 750d | 2006-05-01 | 2009-03-13 | 470d | start no earlier than 2006-05-01 | designer [300%] | 18000h |
